# Binak Oilfiield Development,New Gas Commpressor Station

Schedule from MS Project, 2023-11-08 to 2025-01-08, status date 2023-07-03.

## Calendars

- Standard: Mon-Tue 07:00-16:00; Wed 07:00-15:00; Thu-Fri off; Sat-Sun 07:00-16:00.

## Schedule

| ID | WBS | Task | Type | Duration | Start | Finish | Predecessors | Total slack | Free slack | Start Date | Finish Date |
| --- | --- | --- | --- | --- | --- | --- | --- | --- | --- | --- | --- |
| 1 | 1 | **project Air Cooler(Binak Oilfield Development , New Gas Commpressor Station)** |  | 336d | 2023-11-08 | 2025-01-08 |  | 0d |  | 102/8/17 | 103/10/19 |
| 2 | 1.1 | **Milestones** |  | 336d | 2023-11-08 | 2025-01-08 |  | 0d |  | 102/8/17 | 103/10/19 |
| 3 | 1.1.1 | Project start | milestone | 0d | 2023-11-08 | 2023-11-08 | 4 | 0d |  | 102/8/17 | 102/8/17 |
| 4 | 1.1.2 | 1St payment 15% (Adv. Payment) | milestone | 0d | 2023-11-08 | 2023-11-08 |  | 0d |  | 102/8/17 | 102/8/17 |
| 5 | 1.1.3 | 2nd payment 5% (Against Submission Of GA Drawing) | milestone | 0d | 2023-11-08 | 2023-11-08 |  | 336d |  | 102/8/17 | 102/8/17 |
| 6 | 1.1.4 | 3rd payment 40% (Againt Unpriced Proforma Invoice Of Main Raw Material(Plate & Tube)) | milestone | 0d | 2024-03-23 | 2024-03-23 | 21, 22, 40, 44 | 230d |  | 103/1/4 | 103/1/4 |
| 7 | 1.1.5 | 4rd payment 15% (Against Submission Main Raw Material IRN At Material Vendor,s Shop) | milestone | 0d | 2024-12-02 | 2024-12-02 | 26, 42, 46 | 30d |  | 103/9/12 | 103/9/12 |
| 8 | 1.1.6 | 5rd payment 20% (Against Submission Of Shipping Document) | milestone | 0d | 2025-01-08 | 2025-01-08 | 155, 156, 157, 158, 160, 161, 162, 163 | 0d |  | 103/10/19 | 103/10/19 |
| 9 | 1.1.7 | 6rd payment 5% (Against Final Data Book) | milestone | 0d | 2025-01-08 | 2025-01-08 | 166 | 0d |  | 103/10/19 | 103/10/19 |
| 10 | 1.1.8 | Project finish | milestone | 0d | 2025-01-08 | 2025-01-08 | 166 | 0d |  | 103/10/19 | 103/10/19 |
| 11 | 1.2 | **Engineering** |  | 151d | 2023-11-08 | 2024-05-19 |  | 0d |  | 102/8/17 | 103/2/30 |
| 12 | 1.2.1 | process |  | 65d | 2023-11-11 | 2024-01-31 | 16SS+1d | 0d |  | 102/8/20 | 102/11/11 |
| 13 | 1.2.2 | Mechanical |  | 140d | 2023-11-22 | 2024-05-19 | 12SS+10d | 0d |  | 102/9/1 | 103/2/30 |
| 14 | 1.2.3 | Electrical & Instrument |  | 90d | 2023-12-05 | 2024-03-30 | 12SS+10d, 13SS+10d | 5d | 0d | 102/9/14 | 103/1/11 |
| 15 | 1.2.4 | Civil & Structure |  | 95d | 2023-12-18 | 2024-04-16 | 13SS+20d | 27d | 10d | 102/9/27 | 103/1/28 |
| 16 | 1.2.5 | General |  | 126d | 2023-11-08 | 2024-04-16 | 3 | 0d |  | 102/8/17 | 103/1/28 |
| 17 | 1.2.6 | Material |  | 60d | 2024-01-13 | 2024-03-30 | 12SS+50d, 16SS+50d | 225d |  | 102/10/23 | 103/1/11 |
| 18 | 1.2.7 | QC |  | 60d | 2024-01-13 | 2024-03-30 | 13SS+40d | 225d |  | 102/10/23 | 103/1/11 |
| 19 | 1.3 | **Raw Material/Supply** |  | 250d | 2024-01-24 | 2024-12-08 |  | 0d |  | 102/11/4 | 103/9/18 |
| 20 | 1.3.1 | **Plates For Header Box** |  | 234d | 2024-01-24 | 2024-11-18 |  | 0d |  | 102/11/4 | 103/8/28 |
| 21 | 1.3.1.1 | Inquiry for Plates For Header Box |  | 19d | 2024-01-24 | 2024-02-18 | 13SS+50d | 0d |  | 102/11/4 | 102/11/29 |
| 22 | 1.3.1.2 | Po Placement for Plates For Header Box |  | 10d | 2024-02-18 | 2024-03-02 | 21 | 0d |  | 102/11/29 | 102/12/12 |
| 23 | 1.3.1.3 | Fabrication for Plates For Header Box |  | 130d | 2024-03-03 | 2024-08-14 | 22 | 0d |  | 102/12/13 | 103/5/24 |
| 24 | 1.3.1.4 | Shipping for Plates For Header Box |  | 30d | 2024-08-14 | 2024-09-22 | 23 | 0d |  | 103/5/24 | 103/7/1 |
| 25 | 1.3.1.5 | Custom Clearance for Plates For Header Box |  | 30d | 2024-09-22 | 2024-10-29 | 24 | 0d |  | 103/7/1 | 103/8/8 |
| 26 | 1.3.1.6 | Deliver to Vendor ShopPlates For Header Box |  | 15d | 2024-10-29 | 2024-11-18 | 25 | 0d |  | 103/8/8 | 103/8/28 |

| ID | WBS | Task | Duration | Start | Finish | Predecessors | Total slack | Free slack | Start Date | Finish Date |
| --- | --- | --- | --- | --- | --- | --- | --- | --- | --- | --- |
| 27 | 1.3.2 | **Flange - Flange Gasket** | 140d | 2024-02-06 | 2024-08-03 |  | 90d |  | 102/11/17 | 103/5/13 |
| 28 | 1.3.2.1 | Po Placement for Flange - Flange Gasket | 20d | 2024-02-06 | 2024-03-03 | 13SS+60d | 90d | 0d | 102/11/17 | 102/12/13 |
| 29 | 1.3.2.2 | Fabrication for Flange - Flange Gasket | 100d | 2024-03-03 | 2024-07-08 | 28 | 90d | 0d | 102/12/13 | 103/4/18 |
| 30 | 1.3.2.3 | Deliver to Vendor ShopFlange - Flange Gasket | 20d | 2024-07-08 | 2024-08-03 | 29 | 90d |  | 103/4/18 | 103/5/13 |
| 31 | 1.3.3 | **Nozzle Pipe/Transition Nozzle** | 140d | 2024-02-06 | 2024-08-03 |  | 84d |  | 102/11/17 | 103/5/13 |
| 32 | 1.3.3.1 | Po Placement for Nozzle Pipe/Transition Nozzle | 20d | 2024-02-06 | 2024-03-03 | 13SS+60d | 84d | 0d | 102/11/17 | 102/12/13 |
| 33 | 1.3.3.2 | Fabrication for Nozzle Pipe/Transition Nozzle | 100d | 2024-03-03 | 2024-07-08 | 32 | 84d | 0d | 102/12/13 | 103/4/18 |
| 34 | 1.3.3.3 | Deliver to Vendor ShopNozzle Pipe/Transition Nozzle | 20d | 2024-07-08 | 2024-08-03 | 33 | 84d |  | 103/4/18 | 103/5/13 |
| 35 | 1.3.4 | **Plug -Plug Gasket** | 140d | 2024-02-06 | 2024-08-03 |  | 89d |  | 102/11/17 | 103/5/13 |
| 36 | 1.3.4.1 | Po Placement for Plug -Plug Gasket | 20d | 2024-02-06 | 2024-03-03 | 13SS+60d | 89d | 0d | 102/11/17 | 102/12/13 |
| 37 | 1.3.4.2 | Fabrication for Plug -Plug Gasket | 100d | 2024-03-03 | 2024-07-08 | 36 | 89d | 0d | 102/12/13 | 103/4/18 |
| 38 | 1.3.4.3 | Deliver to Vendor ShopPlug -Plug Gasket | 20d | 2024-07-08 | 2024-08-03 | 37 | 89d |  | 103/4/18 | 103/5/13 |
| 39 | 1.3.5 | **Core Tubes** | 220d | 2024-02-26 | 2024-12-02 |  | 4d |  | 102/12/7 | 103/9/12 |
| 40 | 1.3.5.1 | Po Placement for Core Tubes | 20d | 2024-02-26 | 2024-03-23 | 13SS+75d | 4d | 0d | 102/12/7 | 103/1/4 |
| 41 | 1.3.5.2 | Fabrication for Core Tubes | 180d | 2024-03-23 | 2024-11-06 | 40 | 4d | 0d | 103/1/4 | 103/8/16 |
| 42 | 1.3.5.3 | Deliver to Vendor ShopCore Tubes | 20d | 2024-11-06 | 2024-12-02 | 41 | 4d | 0d | 103/8/16 | 103/9/12 |
| 43 | 1.3.6 | **Al.Tubes** | 220d | 2024-02-26 | 2024-12-02 |  | 4d |  | 102/12/7 | 103/9/12 |
| 44 | 1.3.6.1 | Po Placement for Al.Tubes | 20d | 2024-02-26 | 2024-03-23 | 13SS+75d | 4d | 0d | 102/12/7 | 103/1/4 |
| 45 | 1.3.6.2 | Fabrication for Al.Tubes | 180d | 2024-03-23 | 2024-11-06 | 44 | 4d | 0d | 103/1/4 | 103/8/16 |
| 46 | 1.3.6.3 | Deliver to Vendor Shop Al.Tubes | 20d | 2024-11-06 | 2024-12-02 | 45 | 4d | 0d | 103/8/16 | 103/9/12 |
| 47 | 1.3.7 | **All Nut & Bolts** | 120d | 2024-05-26 | 2024-10-26 |  | 40d |  | 103/3/6 | 103/8/5 |
| 48 | 1.3.7.1 | Po Placement for All Nut & Bolts | 10d | 2024-05-26 | 2024-06-08 | 13SS+145d, 15SS+115d | 40d | 0d | 103/3/6 | 103/3/19 |
| 49 | 1.3.7.2 | Fabrication for All Nut & Bolts | 100d | 2024-06-08 | 2024-10-12 | 48 | 40d | 0d | 103/3/19 | 103/7/21 |
| 50 | 1.3.7.3 | Deliver to Vendor ShopAll Nut & Bolts | 10d | 2024-10-13 | 2024-10-26 | 49 | 40d | 38d | 103/7/22 | 103/8/5 |

| ID | WBS | Task | Duration | Start | Finish | Predecessors | Total slack | Free slack | Start Date | Finish Date |
| --- | --- | --- | --- | --- | --- | --- | --- | --- | --- | --- |
| 51 | 1.3.8 | **Stud Bolt** | 110d | 2024-06-01 | 2024-10-19 |  | 49d |  | 103/3/12 | 103/7/28 |
| 52 | 1.3.8.1 | Po Placement for Stud Bolt | 10d | 2024-06-01 | 2024-06-12 | 13FS+10d | 49d | 0d | 103/3/12 | 103/3/23 |
| 53 | 1.3.8.2 | Fabrication for Stud Bolt | 90d | 2024-06-12 | 2024-10-06 | 52 | 49d | 0d | 103/3/23 | 103/7/15 |
| 54 | 1.3.8.3 | Deliver to Vendor ShopStud Bolt | 10d | 2024-10-06 | 2024-10-19 | 53 | 49d |  | 103/7/15 | 103/7/28 |
| 55 | 1.3.9 | **Plate - Profile for Side Frame** | 140d | 2024-04-10 | 2024-10-06 |  | 4d |  | 103/1/22 | 103/7/15 |
| 56 | 1.3.9.1 | Po Placement for Plate - Profile for Side Frame | 10d | 2024-04-10 | 2024-04-23 | 13SS+110d | 4d | 0d | 103/1/22 | 103/2/4 |
| 57 | 1.3.9.2 | Fabrication for Plate - Profile for Side Frame | 120d | 2024-04-23 | 2024-09-23 | 56 | 4d | 0d | 103/2/4 | 103/7/2 |
| 58 | 1.3.9.3 | Deliver to Vendor ShopPlate - Profile for Side Frame | 10d | 2024-09-23 | 2024-10-06 | 57 | 4d | 0d | 103/7/2 | 103/7/15 |
| 59 | 1.3.10 | **Bearing Block** | 140d | 2024-05-26 | 2024-11-19 |  | 10d |  | 103/3/6 | 103/8/29 |
| 60 | 1.3.10.1 | Po Placement for Bearing Block | 20d | 2024-05-26 | 2024-06-19 | 13SS+145d | 10d | 0d | 103/3/6 | 103/3/30 |
| 61 | 1.3.10.2 | Fabrication for Bearing Block | 100d | 2024-06-19 | 2024-10-26 | 60 | 10d | 0d | 103/3/30 | 103/8/5 |
| 62 | 1.3.10.3 | Deliver to Vendor ShopBearing Block | 20d | 2024-10-26 | 2024-11-19 | 61 | 10d | 0d | 103/8/5 | 103/8/29 |
| 63 | 1.3.11 | **Steel Structure & Fan & Motor Support** | 140d | 2024-05-26 | 2024-11-19 |  | 2d |  | 103/3/6 | 103/8/29 |
| 64 | 1.3.11.1 | Po Placement for Steel Structure & Fan & Motor Support | 20d | 2024-05-26 | 2024-06-19 | 13FS+5d, 15FS+5d | 2d | 0d | 103/3/6 | 103/3/30 |
| 65 | 1.3.11.2 | Fabrication for Steel Structure & Fan & Motor Support | 100d | 2024-06-19 | 2024-10-26 | 64 | 2d | 0d | 103/3/30 | 103/8/5 |
| 66 | 1.3.11.3 | Deliver to Vendor ShopSteel Structure & Fan & Motor Support | 20d | 2024-10-26 | 2024-11-19 | 65 | 2d | 0d | 103/8/5 | 103/8/29 |
| 67 | 1.3.12 | **Grating & Grating Clamps** | 130d | 2024-05-26 | 2024-11-06 |  | 20d |  | 103/3/6 | 103/8/16 |
| 68 | 1.3.12.1 | Po Placement for Grating & Grating Clamps | 20d | 2024-05-26 | 2024-06-19 | 13FS+5d, 15FS+5d | 20d | 0d | 103/3/6 | 103/3/30 |
| 69 | 1.3.12.2 | Fabrication for Grating & Grating Clamps | 90d | 2024-06-19 | 2024-10-12 | 68 | 20d | 0d | 103/3/30 | 103/7/21 |
| 70 | 1.3.12.3 | Deliver to Vendor ShopGrating & Grating Clamps | 20d | 2024-10-13 | 2024-11-06 | 69 | 20d | 10d | 103/7/22 | 103/8/16 |
| 71 | 1.3.13 | **Fan Ring & Plenum** | 150d | 2024-05-19 | 2024-11-25 |  | 10d |  | 103/2/30 | 103/9/5 |
| 72 | 1.3.13.1 | Po Placement for PlateFan Ring & Plenum | 20d | 2024-05-19 | 2024-06-12 | 13 | 10d | 0d | 103/2/30 | 103/3/23 |
| 73 | 1.3.13.2 | Fabrication for PlateFan Ring & Plenum | 110d | 2024-06-12 | 2024-10-30 | 72 | 10d | 0d | 103/3/23 | 103/8/9 |
| 74 | 1.3.13.3 | Deliver to Vendor ShopFan Ring & Plenum | 20d | 2024-10-30 | 2024-11-25 | 73 | 10d | 0d | 103/8/9 | 103/9/5 |

| ID | WBS | Task | Duration | Start | Finish | Predecessors | Total slack | Free slack | Start Date | Finish Date |
| --- | --- | --- | --- | --- | --- | --- | --- | --- | --- | --- |
| 75 | 1.3.14 | **Louver** | 150d | 2024-05-12 | 2024-11-19 |  | 10d |  | 103/2/23 | 103/8/29 |
| 76 | 1.3.14.1 | Po Placement for PlateLouver | 20d | 2024-05-12 | 2024-06-08 | 13FS-5d | 10d | 0d | 103/2/23 | 103/3/19 |
| 77 | 1.3.14.2 | Fabrication for PlateLouver | 110d | 2024-06-08 | 2024-10-26 | 76 | 10d | 0d | 103/3/19 | 103/8/5 |
| 78 | 1.3.14.3 | Deliver to Vendor ShopLouver | 20d | 2024-10-26 | 2024-11-19 | 77 | 10d | 0d | 103/8/5 | 103/8/29 |
| 79 | 1.3.15 | **Fan Guard & Pully Guard** | 130d | 2024-05-12 | 2024-10-26 |  | 35d |  | 103/2/23 | 103/8/5 |
| 80 | 1.3.15.1 | Po Placement for PlateFan Guard & Pully Guard | 20d | 2024-05-12 | 2024-06-08 | 13FS-5d | 35d | 0d | 103/2/23 | 103/3/19 |
| 81 | 1.3.15.2 | Fabrication for PlateFan Guard & Pully Guard | 90d | 2024-06-08 | 2024-09-29 | 80 | 35d | 0d | 103/3/19 | 103/7/8 |
| 82 | 1.3.15.3 | Deliver to Vendor ShopFan Guard & Pully Guard | 20d | 2024-09-29 | 2024-10-26 | 81 | 35d | 25d | 103/7/8 | 103/8/5 |
| 83 | 1.3.16 | **I/P Convertor** | 170d | 2024-04-16 | 2024-11-19 |  | 20d |  | 103/1/28 | 103/8/29 |
| 84 | 1.3.16.1 | Inquiry for PlateI/P Convertor | 10d | 2024-04-16 | 2024-04-29 | 14FS+15d | 20d | 0d | 103/1/28 | 103/2/10 |
| 85 | 1.3.16.2 | Po Placement for PlateI/P Convertor | 10d | 2024-04-29 | 2024-05-12 | 84 | 20d | 0d | 103/2/10 | 103/2/23 |
| 86 | 1.3.16.3 | Fabrication for PlateI/P Convertor | 120d | 2024-05-12 | 2024-10-12 | 85 | 20d | 0d | 103/2/23 | 103/7/21 |
| 87 | 1.3.16.4 | Shipping for PlateI/P Convertor | 10d | 2024-10-13 | 2024-10-26 | 86 | 20d | 0d | 103/7/22 | 103/8/5 |
| 88 | 1.3.16.5 | Custom Clearance for PlateI/P Convertor | 10d | 2024-10-26 | 2024-11-06 | 87 | 20d | 0d | 103/8/5 | 103/8/16 |
| 89 | 1.3.16.6 | Deliver to Vendor ShopI/P Convertor | 10d | 2024-11-06 | 2024-11-19 | 88 | 20d | 15d | 103/8/16 | 103/8/29 |
| 90 | 1.3.17 | **Motor** | 160d | 2024-05-06 | 2024-11-25 |  | 15d |  | 103/2/17 | 103/9/5 |
| 91 | 1.3.17.1 | Inquiry for PlateMotor | 20d | 2024-05-06 | 2024-06-01 | 14FS+30d | 15d | 0d | 103/2/17 | 103/3/12 |
| 92 | 1.3.17.2 | Po Placement for PlateMotor | 20d | 2024-06-01 | 2024-06-25 | 91 | 15d | 0d | 103/3/12 | 103/4/5 |
| 93 | 1.3.17.3 | Fabrication for PlateMotor | 80d | 2024-06-25 | 2024-10-06 | 92 | 15d | 0d | 103/4/5 | 103/7/15 |
| 94 | 1.3.17.4 | Shipping for PlateMotor | 20d | 2024-10-06 | 2024-10-30 | 93 | 15d | 0d | 103/7/15 | 103/8/9 |
| 95 | 1.3.17.5 | Custom Clearance for PlateMotor | 10d | 2024-10-30 | 2024-11-12 | 94 | 15d | 0d | 103/8/9 | 103/8/22 |
| 96 | 1.3.17.6 | Deliver to Vendor ShopMotor | 10d | 2024-11-12 | 2024-11-25 | 95 | 15d | 10d | 103/8/22 | 103/9/5 |
| 97 | 1.3.18 | **Vibration Switch** | 190d | 2024-04-10 | 2024-12-08 |  | 5d |  | 103/1/22 | 103/9/18 |
| 98 | 1.3.18.1 | Inquiry for PlateVibration Switch | 20d | 2024-04-10 | 2024-05-06 | 14SS+100d | 5d | 0d | 103/1/22 | 103/2/17 |
| 99 | 1.3.18.2 | Po Placement for PlateVibration Switch | 20d | 2024-05-06 | 2024-06-01 | 98 | 5d | 0d | 103/2/17 | 103/3/12 |
| 100 | 1.3.18.3 | Fabrication for PlateVibration Switch | 110d | 2024-06-01 | 2024-10-19 | 99 | 5d | 0d | 103/3/12 | 103/7/28 |
| 101 | 1.3.18.4 | Shipping for PlateVibration Switch | 20d | 2024-10-19 | 2024-11-12 | 100 | 5d | 0d | 103/7/28 | 103/8/22 |
| 102 | 1.3.18.5 | Custom Clearance for PlateVibration Switch | 10d | 2024-11-12 | 2024-11-25 | 101 | 5d | 0d | 103/8/22 | 103/9/5 |
| 103 | 1.3.18.6 | Deliver to Vendor ShopVibration Switch | 10d | 2024-11-25 | 2024-12-08 | 102 | 5d | 0d | 103/9/5 | 103/9/18 |

| ID | WBS | Task | Duration | Start | Finish | Predecessors | Total slack | Free slack | Start Date | Finish Date |
| --- | --- | --- | --- | --- | --- | --- | --- | --- | --- | --- |
| 104 | 1.3.19 | **Fan** | 210d | 2024-03-17 | 2024-12-08 |  | 5d |  | 102/12/27 | 103/9/18 |
| 105 | 1.3.19.1 | Inquiry for PlateFan | 20d | 2024-03-17 | 2024-04-10 | 13SS+90d | 5d | 0d | 102/12/27 | 103/1/22 |
| 106 | 1.3.19.2 | Po Placement for PlateFan | 20d | 2024-04-10 | 2024-05-06 | 105 | 5d | 0d | 103/1/22 | 103/2/17 |
| 107 | 1.3.19.3 | Fabrication for PlateFan | 110d | 2024-05-06 | 2024-09-23 | 106 | 5d | 0d | 103/2/17 | 103/7/2 |
| 108 | 1.3.19.4 | Shipping for PlateFan | 30d | 2024-09-23 | 2024-10-30 | 107 | 5d | 0d | 103/7/2 | 103/8/9 |
| 109 | 1.3.19.5 | Custom Clearance for PlateFan | 20d | 2024-10-30 | 2024-11-25 | 108 | 5d | 0d | 103/8/9 | 103/9/5 |
| 110 | 1.3.19.6 | Deliver to Vendor ShopFan | 10d | 2024-11-25 | 2024-12-08 | 109 | 5d | 0d | 103/9/5 | 103/9/18 |
| 111 | 1.3.20 | **Bellt & Pully** | 140d | 2024-06-08 | 2024-12-02 |  | 10d |  | 103/3/19 | 103/9/12 |
| 112 | 1.3.20.1 | Inquiry for Plate Bellt & Pully | 10d | 2024-06-08 | 2024-06-19 | 13FS+15d | 10d | 0d | 103/3/19 | 103/3/30 |
| 113 | 1.3.20.2 | Po Placement for Plate Bellt & Pully | 10d | 2024-06-19 | 2024-07-02 | 112 | 10d | 0d | 103/3/30 | 103/4/12 |
| 114 | 1.3.20.3 | Fabrication for Plate Bellt & Pully | 80d | 2024-07-02 | 2024-10-12 | 113 | 10d | 0d | 103/4/12 | 103/7/21 |
| 115 | 1.3.20.4 | Shipping for Plate Bellt & Pully | 20d | 2024-10-13 | 2024-11-06 | 114 | 10d | 0d | 103/7/22 | 103/8/16 |
| 116 | 1.3.20.5 | Custom Clearance for Plate Bellt & Pully | 10d | 2024-11-06 | 2024-11-19 | 115 | 10d | 0d | 103/8/16 | 103/8/29 |
| 117 | 1.3.20.6 | Deliver to Vendor Shop Bellt & Pully | 10d | 2024-11-19 | 2024-12-02 | 116 | 10d | 5d | 103/8/29 | 103/9/12 |
| 118 | 1.4 | **Manufacturing** | 44d | 2024-10-30 | 2024-12-25 |  | 0d |  | 103/8/9 | 103/10/5 |
| 119 | 1.4.1 | **Air Cooler Tag No. AE-2101 (A / B / C)** | 44d | 2024-10-30 | 2024-12-25 |  | 0d |  | 103/8/9 | 103/10/5 |
| 120 | 1.4.1.1 | **Fabrication Of Header Box** | 30d | 2024-11-18 | 2024-12-25 |  | 0d |  | 103/8/28 | 103/10/5 |
| 121 | 1.4.1.1.1 | Cutting | 5d | 2024-11-18 | 2024-11-24 | 26, 34 | 0d |  | 103/8/28 | 103/9/4 |
| 122 | 1.4.1.1.2 | Assembly | 5d | 2024-11-23 | 2024-11-27 | 121FS-2d, 26 | 0d |  | 103/9/3 | 103/9/7 |
| 123 | 1.4.1.1.3 | Welding | 5d | 2024-11-25 | 2024-12-02 | 122FS-2d, 30 | 0d |  | 103/9/5 | 103/9/12 |
| 124 | 1.4.1.1.4 | CNC | 5d | 2024-11-30 | 2024-12-07 | 123FS-2d | 0d |  | 103/9/10 | 103/9/17 |
| 125 | 1.4.1.1.5 | Nozzle & Flang Assembly | 5d | 2024-12-03 | 2024-12-09 | 124FS-2d | 0d |  | 103/9/13 | 103/9/19 |
| 126 | 1.4.1.1.6 | Final Machining | 5d | 2024-12-08 | 2024-12-14 | 125FS-2d | 0d |  | 103/9/18 | 103/9/24 |
| 127 | 1.4.1.1.7 | Coating | 5d | 2024-12-10 | 2024-12-17 | 126FS-2d | 0d |  | 103/9/20 | 103/9/27 |
| 128 | 1.4.1.1.8 | Assembly / test of Tube Bundle | 7d | 2024-12-17 | 2024-12-25 | 127, 133, 135 | 0d |  | 103/9/27 | 103/10/5 |

| ID | WBS | Task | Duration | Start | Finish | Predecessors | Total slack | Free slack | Start Date | Finish Date |
| --- | --- | --- | --- | --- | --- | --- | --- | --- | --- | --- |
| 129 | 1.4.1.2 | **Fabrication Of Bundle Frame** | 33d | 2024-10-30 | 2024-12-11 |  | 4d |  | 103/8/9 | 103/9/21 |
| 130 | 1.4.1.2.1 | Cutting | 5d | 2024-10-30 | 2024-11-06 | 58FS+20d | 4d | 0d | 103/8/9 | 103/8/16 |
| 131 | 1.4.1.2.2 | Assembly | 5d | 2024-11-12 | 2024-11-19 | 130FS+5d | 4d | 0d | 103/8/22 | 103/8/29 |
| 132 | 1.4.1.2.3 | Welding | 5d | 2024-11-25 | 2024-12-02 | 131FS+5d | 4d | 0d | 103/9/5 | 103/9/12 |
| 133 | 1.4.1.2.4 | Coating | 8d | 2024-12-02 | 2024-12-11 | 132 | 4d |  | 103/9/12 | 103/9/21 |
| 134 | 1.4.1.3 | **Fabrication Of Fin Tube** | 8d | 2024-12-02 | 2024-12-11 |  | 4d |  | 103/9/12 | 103/9/21 |
| 135 | 1.4.1.3.1 | Fabrication Of Fin Tube | 8d | 2024-12-02 | 2024-12-11 | 42, 46 | 4d |  | 103/9/12 | 103/9/21 |
| 136 | 1.4.2 | **Air Cooler Tag No. AE-2102 (A / B / C)** | 34d | 2024-11-12 | 2024-12-25 |  | 0d |  | 103/8/22 | 103/10/5 |
| 137 | 1.4.2.1 | **Fabrication Of Header Box** | 30d | 2024-11-18 | 2024-12-25 |  | 0d |  | 103/8/28 | 103/10/5 |
| 138 | 1.4.2.1.1 | Cutting | 7d | 2024-11-18 | 2024-11-26 | 26, 34 | 0d |  | 103/8/28 | 103/9/6 |
| 139 | 1.4.2.1.2 | Assembly | 5d | 2024-11-24 | 2024-12-01 | 121FS-2d, 26, 38, 138FS-2d | 0d |  | 103/9/4 | 103/9/11 |
| 140 | 1.4.2.1.3 | Welding | 5d | 2024-11-27 | 2024-12-04 | 122FS-2d, 139FS-2d | 0d |  | 103/9/7 | 103/9/14 |
| 141 | 1.4.2.1.4 | CNC | 5d | 2024-12-02 | 2024-12-08 | 123FS-2d, 140FS-2d | 0d |  | 103/9/12 | 103/9/18 |
| 142 | 1.4.2.1.5 | Nozzle & Flang Assembly | 5d | 2024-12-07 | 2024-12-11 | 124FS-2d, 141FS-2d | 0d |  | 103/9/17 | 103/9/21 |
| 143 | 1.4.2.1.6 | Final Machining | 5d | 2024-12-09 | 2024-12-16 | 125FS-2d, 142FS-2d | 0d |  | 103/9/19 | 103/9/26 |
| 144 | 1.4.2.1.7 | Coating | 5d | 2024-12-14 | 2024-12-21 | 126FS-2d, 143FS-2d | 0d |  | 103/9/24 | 103/10/1 |
| 145 | 1.4.2.1.8 | Assembly /test of Tube Bundle | 5d | 2024-12-21 | 2024-12-25 | 127, 54, 133, 135SS, 144, 150, 152SS+10d | 0d |  | 103/10/1 | 103/10/5 |
| 146 | 1.4.2.2 | **Fabrication Of Bundle Frame** | 23d | 2024-11-12 | 2024-12-11 |  | 6d |  | 103/8/22 | 103/9/21 |
| 147 | 1.4.2.2.1 | Cutting | 5d | 2024-11-12 | 2024-11-19 | 58FS+30d | 6d | 0d | 103/8/22 | 103/8/29 |
| 148 | 1.4.2.2.2 | Assembly | 5d | 2024-11-19 | 2024-11-25 | 147 | 6d | 0d | 103/8/29 | 103/9/5 |
| 149 | 1.4.2.2.3 | Welding | 5d | 2024-11-25 | 2024-12-02 | 148 | 6d | 0d | 103/9/5 | 103/9/12 |
| 150 | 1.4.2.2.4 | Coating | 8d | 2024-12-02 | 2024-12-11 | 149 | 6d |  | 103/9/12 | 103/9/21 |
| 151 | 1.4.2.3 | **Fabrication Of Fin Tube** | 8d | 2024-12-02 | 2024-12-11 |  | 4d |  | 103/9/12 | 103/9/21 |
| 152 | 1.4.2.3.1 | Fabrication Of Fin Tube | 8d | 2024-12-02 | 2024-12-11 | 42, 46 | 4d |  | 103/9/12 | 103/9/21 |

| ID | WBS | Task | Duration | Start | Finish | Predecessors | Total slack | Free slack | Start Date | Finish Date |
| --- | --- | --- | --- | --- | --- | --- | --- | --- | --- | --- |
| 153 | 1.5 | **Inspection / Delivery** | 40d | 2024-11-19 | 2025-01-08 |  | 0d |  | 103/8/29 | 103/10/19 |
| 154 | 1.5.1 | **Air Cooler Tag No. AE-2101 (A / B / C)** | 40d | 2024-11-19 | 2025-01-08 |  | 0d |  | 103/8/29 | 103/10/19 |
| 155 | 1.5.1.1 | Tube Bundle | 10d | 2024-12-28 | 2025-01-08 | 128FS+1d, 145FS+1d | 0d |  | 103/10/8 | 103/10/19 |
| 156 | 1.5.1.2 | Steel Structure & MOT | 18d | 2024-11-19 | 2024-12-11 | 66 | 2d | 0d | 103/8/29 | 103/9/21 |
| 157 | 1.5.1.3 | Accessories | 15d | 2024-11-25 | 2024-12-15 | 82, 74, 62, 70, 78 | 20d |  | 103/9/5 | 103/9/25 |
| 158 | 1.5.1.4 | Equipment | 10d | 2024-12-22 | 2025-01-04 | 117FS+10d, 110FS+10d, 103FS+10d, 96FS+10d, 89FS+10d | 5d |  | 103/10/2 | 103/10/15 |
| 159 | 1.5.2 | **Air Cooler Tag No. AE-2102 (A / B / C)** | 25d | 2024-12-08 | 2025-01-08 |  | 0d |  | 103/9/18 | 103/10/19 |
| 160 | 1.5.2.1 | Tube Bundle | 10d | 2024-12-28 | 2025-01-08 | 128FS+1d, 145FS+1d | 0d |  | 103/10/8 | 103/10/19 |
| 161 | 1.5.2.2 | Steel Structure & MOT | 20d | 2024-12-11 | 2025-01-06 | 156, 50 | 2d |  | 103/9/21 | 103/10/17 |
| 162 | 1.5.2.3 | Accessories | 15d | 2024-12-08 | 2024-12-28 | 82FS+10d, 74FS+10d, 62FS+15d, 70FS+15d, 78FS+15d, 66FS+15d | 10d |  | 103/9/18 | 103/10/8 |
| 163 | 1.5.2.4 | Equipment | 10d | 2024-12-22 | 2025-01-04 | 117FS+10d, 110FS+10d, 103FS+10d, 96FS+10d, 89FS+10d | 5d |  | 103/10/2 | 103/10/15 |
| 164 | 1.6 | **Final book** | 6d | 2025-01-01 | 2025-01-08 |  | 0d |  | 103/10/12 | 103/10/19 |
| 165 | 1.6.1 | Final Data Book Index for Air Coolers | 6d | 2025-01-01 | 2025-01-08 | 158FF, 163FF, 160FF | 0d |  | 103/10/12 | 103/10/19 |
| 166 | 1.6.2 | Final Data Book for Air Coolers | 6d | 2025-01-01 | 2025-01-08 | 165SS | 0d |  | 103/10/12 | 103/10/19 |
